# کسب دانش فنی و تولید بخشی از مواد شیمیایی پر مصرف صنعت نفت و گاز

Schedule from MS Project, 2019-10-23 to 2021-10-22, status date 2020-11-20, A marks actual dates.

## Calendars

- Standard: Mon-Sun 08:00-12:00, 13:00-17:00. Exceptions (off unless hours are given): 2020-03-19 to 2020-04-03 (تعطیلات نوروز).

## Schedule

| ID | WBS | Task | Duration | Start | Finish | Predecessors | Complete | Remaining | Total slack | شروع شمسی | پایان شمسی |
| --- | --- | --- | --- | --- | --- | --- | --- | --- | --- | --- | --- |
| 1 | 1 | **کسب دانش فنی و تولید ماده ضد خوردگی محلول در آب** | 715d | 2019-10-23 A | 2021-10-22 |  | 15% | 608.06d | 0d | 98/8/1 | 100/7/30 |
| 2 | 1.1 | **فاز مطالعاتی** | 105d | 2019-10-23 A | 2020-02-04 A |  | 100% |  |  | 98/8/1 | 98/11/15 |
| 3 | 1.1.1 | **جمع آوری اطلاعات** | 30d | 2019-10-23 A | 2019-11-21 A |  | 100% |  |  | 98/8/1 | 98/8/30 |
| 4 | 1.1.1.1 | مطالعات کتابخانه ای | 30d | 2019-10-23 A | 2019-11-21 A |  | 100% |  |  | 98/8/1 | 98/8/30 |
| 5 | 1.1.1.2 | جمع آوری سوابق اجرای طرح | 30d | 2019-10-23 A | 2019-11-21 A | 4SS | 100% |  |  | 98/8/1 | 98/8/30 |
| 6 | 1.1.2 | **تکمیل مطالعات** | 75d | 2019-11-22 A | 2020-02-04 A |  | 100% |  |  | 98/9/1 | 98/11/15 |
| 7 | 1.1.2.1 | بررسی اطلاعات و استخراج روش های مناسب سنتز مواد | 60d | 2019-11-22 A | 2020-01-20 A | 5 | 100% |  |  | 98/9/1 | 98/10/30 |
| 8 | 1.1.2.2 | بررسی استانداردها و روشهای شناسایی و تأیید مواد | 60d | 2019-11-22 A | 2020-01-20 A | 7SS | 100% |  |  | 98/9/1 | 98/10/30 |
| 9 | 1.1.2.3 | تهیه گزارش فاز مطالعاتی | 15d | 2020-01-21 A | 2020-02-04 A | 8 | 100% |  |  | 98/11/1 | 98/11/15 |
| 10 | 1.2 | **فاز آزمایشگاهی** | 75d | 2020-02-05 A | 2020-05-05 A |  | 100% |  |  | 98/11/16 | 99/2/16 |
| 11 | 1.2.1 | **طراحی آزمایشها** | 15d | 2020-02-05 A | 2020-02-19 A |  | 100% |  |  | 98/11/16 | 98/11/30 |
| 12 | 1.2.1.1 | استفاده از نرم افزارهاي مرتبط جهت برنامه ريزي آزمایشها | 7d | 2020-02-05 A | 2020-02-11 A | 9 | 100% |  |  | 98/11/16 | 98/11/22 |
| 13 | 1.2.1.2 | تدوين دستور كار تهيه آزمايشگاهي | 8d | 2020-02-12 A | 2020-02-19 A | 12 | 100% |  |  | 98/11/23 | 98/11/30 |
| 14 | 1.2.2 | **خرید مواد و تجهیزات** | 30d | 2020-02-20 A | 2020-04-05 A |  | 100% |  |  | 98/12/1 | 99/1/17 |
| 15 | 1.2.2.1 | استعلام قیمت مواد | 15d | 2020-02-20 A | 2020-03-05 A | 13 | 100% |  |  | 98/12/1 | 98/12/15 |
| 16 | 1.2.2.2 | سفارش خرید مواد | 25d | 2020-02-25 A | 2020-04-05 A | 15SS+5d | 100% |  |  | 98/12/6 | 99/1/17 |
| 17 | 1.2.2.3 | استعلام خرید تجهیزات | 15d | 2020-02-20 A | 2020-03-05 A | 15SS | 100% |  |  | 98/12/1 | 98/12/15 |
| 18 | 1.2.2.4 | خرید تجهیزات سنتز آزمایشگاهی | 25d | 2020-02-25 A | 2020-04-05 A | 17SS+5d | 100% |  |  | 98/12/6 | 99/1/17 |
| 19 | 1.2.3 | **سنتز نمونه های آزمایشگاهی** | 60d | 2020-02-20 A | 2020-05-05 A |  | 100% |  |  | 98/12/1 | 99/2/16 |
| 20 | 1.2.3.1 | سنتز نمونه ها بر اساس طراحی های انجام شده | 15d | 2020-02-20 A | 2020-03-05 A | 13 | 100% |  |  | 98/12/1 | 98/12/15 |
| 21 | 1.2.3.2 | انجام آزمونهای تأییدیه نمونه ها | 15d | 2020-02-20 A | 2020-03-05 A | 20SS | 100% |  |  | 98/12/1 | 98/12/15 |
| 22 | 1.2.3.3 | سنتز نمونه های بهینه | 20d | 2020-03-06 A | 2020-04-10 A | 21 | 100% |  |  | 98/12/16 | 99/1/22 |
| 23 | 1.2.3.4 | دریافت تأییدیه کیفیت از آزمایشگاه مرجع | 20d | 2020-03-06 A | 2020-04-10 A | 22SS | 100% |  |  | 98/12/16 | 99/1/22 |
| 24 | 1.2.3.5 | تهیه گزارش فاز آزمایشگاهی | 30d | 2020-04-06 A | 2020-05-05 A | 23SS+15d | 100% |  |  | 99/1/18 | 99/2/16 |

| ID | WBS | Task | Duration | Start | Finish | Predecessors | Complete | Remaining | Total slack | Free slack | Constraint | شروع شمسی | پایان شمسی |
| --- | --- | --- | --- | --- | --- | --- | --- | --- | --- | --- | --- | --- | --- |
| 25 | 1.3 | **فاز نیمه صنعتی** | 535d | 2020-05-06 A | 2021-10-22 |  | 7% | 498.23d | 0d |  |  | 99/2/17 | 100/7/30 |
| 26 | 1.3.1 | **طراحی خط تولید بر اساس تجهیزات موجود** | 473d | 2020-05-06 A | 2021-08-21 |  | 4% | 454.04d | 62d |  |  | 99/2/17 | 100/5/30 |
| 27 | 1.3.1.1 | طراحی پایه | 15d | 2020-05-06 A | 2020-05-20 A | 24 | 100% |  |  |  |  | 99/2/17 | 99/2/31 |
| 28 | 1.3.1.2 | طراحی تفضیلی | 458d | 2020-05-21 A | 2021-08-21 | 27 | 3% | 443d | 62d | 0d | finish no earlier than 2021-08-21 | 99/3/1 | 100/5/30 |
| 29 | 1.3.1.3 | جانمایی تجهیزات | 450d | 2020-05-29 A | 2021-08-21 | 28SS+8d | 2% | 443d | 62d |  | finish no earlier than 2021-08-21 | 99/3/9 | 100/5/30 |
| 30 | 1.3.2 | **تهیه و ساخت کلیه تجهیزات و مواد مصرفی** | 443d | 2020-06-05 A | 2021-08-21 |  | 8% | 409.15d | 62d |  |  | 99/3/16 | 100/5/30 |
| 31 | 1.3.2.1 | استعلام قیمت تجهیزات مورد نیاز | 10d | 2020-06-05 A | 2020-06-14 A | 29 | 100% |  |  |  |  | 99/3/16 | 99/3/25 |
| 32 | 1.3.2.2 | خرید یا سفارش ساخت تجهیزات | 25d | 2020-06-10 A | 2020-07-04 A | 31SS+5d | 100% |  |  |  |  | 99/3/21 | 99/4/14 |
| 33 | 1.3.2.3 | استعلام قیمت مواد مصرفی جهت تولید نیمه صنعتی | 443d | 2020-06-05 A | 2021-08-21 | 31SS | 2% | 433d | 62d | 5d | finish no earlier than 2021-08-21 | 99/3/16 | 100/5/30 |
| 34 | 1.3.2.4 | خرید مواد مصرفی مورد نیاز | 438d | 2020-06-10 A | 2021-08-21 | 33SS | 6% | 413d | 0d |  | finish no earlier than 2021-08-21 | 99/3/21 | 100/5/30 |
| 35 | 1.3.3 | **نصب و راه اندازی تجهیزات** | 444d | 2020-07-05 A | 2021-09-21 |  | 2% | 435.64d | 31d |  |  | 99/4/15 | 100/6/30 |
| 36 | 1.3.3.1 | نصب تجهیزات خریداری شده | 444d | 2020-07-05 A | 2021-09-21 | 32 | 1% | 439d | 31d |  | finish no earlier than 2021-09-21 | 99/4/15 | 100/6/30 |
| 37 | 1.3.3.2 | تکمیل لوله کشی ها و تاسیسات زیربنایی در صورت نیاز | 5d | 2020-07-10 A | 2020-07-14 A | 36 | 100% |  |  |  |  | 99/4/20 | 99/4/24 |
| 38 | 1.3.3.3 | تطبیق تجهیزات با طراحی های انجام شده و راه اندازی سرد واحد | 5d | 2020-07-10 A | 2020-07-14 A | 36 | 100% |  |  |  |  | 99/4/20 | 99/4/24 |
| 39 | 1.3.3.4 | رفع اشکالات احتمالی | 439d | 2020-07-10 A | 2021-09-21 | 38SS | 1% | 434d | 31d | 5d | finish no earlier than 2021-09-21 | 99/4/20 | 100/6/30 |
| 40 | 1.3.3.5 | راه اندازی گرم سیستم و رفع اشکالات | 434d | 2020-07-15 A | 2021-09-21 | 39SS, 37 | 1% | 429d | 31d | 5d | finish no earlier than 2021-09-21 | 99/4/25 | 100/6/30 |
| 41 | 1.3.4 | **تولید نیمه صنعتی** | 460d | 2020-07-20 A | 2021-10-22 |  | 16% | 386.36d | 0d |  |  | 99/4/30 | 100/7/30 |
| 42 | 1.3.4.1 | تولید محصول در مقیاس پایلوت براساس اعلام نیاز مناطق عملیاتی | 122d | 2020-07-20 A | 2021-10-22 | 40SS, 34 | 49% | 62d | 0d |  | finish no earlier than 2021-10-22 | 99/4/30 | 100/7/30 |
| 43 | 1.3.4.2 | انجام تست میدانی و دریافت تأییدیه از مناطق عملیاتی | 430d | 2020-08-19 A | 2021-10-22 | 42SS+30d | 14% | 370d | 0d |  | finish no earlier than 2021-10-22 | 99/5/29 | 100/7/30 |
| 44 | 1.3.4.3 | گزارش نهایی | 385d | 2020-10-03 A | 2021-10-22 | 43SS+45d | 8% | 355d | 0d |  | finish no earlier than 2021-10-22 | 99/7/12 | 100/7/30 |
| 45 | 2 | **کسب دانش فنی و تولید ماده ضد خوردگی محلول در نفت- دوفازی** | 623d | 2019-10-23 A | 2021-07-22 |  | 32% | 423.55d | 92d |  |  | 98/8/1 | 100/4/31 |
| 46 | 2.1 | **فاز مطالعاتی** | 105d | 2019-10-23 A | 2020-02-04 A |  | 100% |  |  |  |  | 98/8/1 | 98/11/15 |
| 47 | 2.1.1 | **جمع آوری اطلاعات** | 30d | 2019-10-23 A | 2019-11-21 A |  | 100% |  |  |  |  | 98/8/1 | 98/8/30 |
| 48 | 2.1.1.1 | مطالعات کتابخانه ای | 30d | 2019-10-23 A | 2019-11-21 A |  | 100% |  |  |  |  | 98/8/1 | 98/8/30 |
| 49 | 2.1.1.2 | جمع آوری سوابق اجرای طرح | 30d | 2019-10-23 A | 2019-11-21 A | 48SS | 100% |  |  |  |  | 98/8/1 | 98/8/30 |

| ID | WBS | Task | Duration | Start | Finish | Predecessors | Complete | Remaining | Total slack | Constraint | شروع شمسی | پایان شمسی |
| --- | --- | --- | --- | --- | --- | --- | --- | --- | --- | --- | --- | --- |
| 50 | 2.1.2 | **تکمیل مطالعات** | 75d | 2019-11-22 A | 2020-02-04 A |  | 100% |  |  |  | 98/9/1 | 98/11/15 |
| 51 | 2.1.2.1 | بررسی اطلاعات و استخراج روش های مناسب سنتز مواد | 60d | 2019-11-22 A | 2020-01-20 A | 49 | 100% |  |  |  | 98/9/1 | 98/10/30 |
| 52 | 2.1.2.2 | بررسی استانداردها و روشهای شناسایی و تأیید مواد | 60d | 2019-11-22 A | 2020-01-20 A | 51SS | 100% |  |  |  | 98/9/1 | 98/10/30 |
| 53 | 2.1.2.3 | تهیه گزارش فاز مطالعاتی | 15d | 2020-01-21 A | 2020-02-04 A | 52 | 100% |  |  |  | 98/11/1 | 98/11/15 |
| 54 | 2.2 | **فاز آزمایشگاهی** | 75d | 2020-02-05 A | 2020-05-05 A |  | 100% |  |  |  | 98/11/16 | 99/2/16 |
| 55 | 2.2.1 | **طراحی آزمایشها** | 15d | 2020-02-05 A | 2020-02-19 A |  | 100% |  |  |  | 98/11/16 | 98/11/30 |
| 56 | 2.2.1.1 | استفاده از نرم افزارهاي مرتبط جهت برنامه ريزي آزمایشها | 7d | 2020-02-05 A | 2020-02-11 A | 53 | 100% |  |  |  | 98/11/16 | 98/11/22 |
| 57 | 2.2.1.2 | تدوين دستور كار تهيه آزمايشگاهي | 8d | 2020-02-12 A | 2020-02-19 A | 56 | 100% |  |  |  | 98/11/23 | 98/11/30 |
| 58 | 2.2.2 | **خرید مواد و تجهیزات** | 30d | 2020-02-20 A | 2020-04-05 A |  | 100% |  |  |  | 98/12/1 | 99/1/17 |
| 59 | 2.2.2.1 | استعلام قیمت مواد | 15d | 2020-02-20 A | 2020-03-05 A | 57 | 100% |  |  |  | 98/12/1 | 98/12/15 |
| 60 | 2.2.2.2 | سفارش خرید مواد | 25d | 2020-02-25 A | 2020-04-05 A | 59SS+5d | 100% |  |  |  | 98/12/6 | 99/1/17 |
| 61 | 2.2.2.3 | استعلام خرید تجهیزات | 15d | 2020-02-20 A | 2020-03-05 A | 59SS | 100% |  |  |  | 98/12/1 | 98/12/15 |
| 62 | 2.2.2.4 | خرید تجهیزات سنتز آزمایشگاهی | 25d | 2020-02-25 A | 2020-04-05 A | 61SS+5d | 100% |  |  |  | 98/12/6 | 99/1/17 |
| 63 | 2.2.3 | **سنتز نمونه های آزمایشگاهی** | 60d | 2020-02-20 A | 2020-05-05 A |  | 100% |  |  |  | 98/12/1 | 99/2/16 |
| 64 | 2.2.3.1 | سنتز نمونه ها بر اساس طراحی های انجام شده | 15d | 2020-02-20 A | 2020-03-05 A | 57 | 100% |  |  |  | 98/12/1 | 98/12/15 |
| 65 | 2.2.3.2 | انجام آزمونهای تأییدیه نمونه ها | 15d | 2020-02-20 A | 2020-03-05 A | 64SS | 100% |  |  |  | 98/12/1 | 98/12/15 |
| 66 | 2.2.3.3 | سنتز نمونه های بهینه | 20d | 2020-03-06 A | 2020-04-10 A | 65 | 100% |  |  |  | 98/12/16 | 99/1/22 |
| 67 | 2.2.3.4 | دریافت تأییدیه کیفیت از آزمایشگاه مرجع | 20d | 2020-03-06 A | 2020-04-10 A | 66SS | 100% |  |  |  | 98/12/16 | 99/1/22 |
| 68 | 2.2.3.5 | تهیه گزارش فاز آزمایشگاهی | 30d | 2020-04-06 A | 2020-05-05 A | 67SS+15d | 100% |  |  |  | 99/1/18 | 99/2/16 |
| 69 | 2.3 | **فاز نیمه صنعتی** | 443d | 2020-05-06 A | 2021-07-22 |  | 17% | 369.9d | 92d |  | 99/2/17 | 100/4/31 |
| 70 | 2.3.1 | **طراحی خط تولید بر اساس تجهیزات موجود** | 443d | 2020-05-06 A | 2021-07-22 |  | 8% | 406.58d | 92d |  | 99/2/17 | 100/4/31 |
| 71 | 2.3.1.1 | طراحی پایه | 15d | 2020-05-06 A | 2020-05-20 A | 68 | 100% |  |  |  | 99/2/17 | 99/2/31 |
| 72 | 2.3.1.2 | طراحی تفضیلی | 15d | 2020-05-21 A | 2020-06-04 A | 71 | 100% |  |  |  | 99/3/1 | 99/3/15 |
| 73 | 2.3.1.3 | جانمایی تجهیزات | 420d | 2020-05-29 A | 2021-07-22 | 72SS+8d | 2% | 413d | 92d | finish no earlier than 2021-07-22 | 99/3/9 | 100/4/31 |

| ID | WBS | Task | Duration | Start | Finish | Predecessors | Complete | Remaining | Total slack | Constraint | شروع شمسی | پایان شمسی |
| --- | --- | --- | --- | --- | --- | --- | --- | --- | --- | --- | --- | --- |
| 74 | 2.3.2 | **تهیه و ساخت کلیه تجهیزات و مواد مصرفی** | 413d | 2020-06-05 A | 2021-07-22 |  | 15% | 349.18d | 92d |  | 99/3/16 | 100/4/31 |
| 75 | 2.3.2.1 | استعلام قیمت تجهیزات مورد نیاز | 10d | 2020-06-05 A | 2020-06-14 A | 73 | 100% |  |  |  | 99/3/16 | 99/3/25 |
| 76 | 2.3.2.2 | خرید یا سفارش ساخت تجهیزات | 25d | 2020-06-10 A | 2020-07-04 A | 75SS+5d | 100% |  |  |  | 99/3/21 | 99/4/14 |
| 77 | 2.3.2.3 | استعلام قیمت مواد مصرفی جهت تولید نیمه صنعتی | 10d | 2020-06-05 A | 2020-06-14 A | 75SS | 100% |  |  |  | 99/3/16 | 99/3/25 |
| 78 | 2.3.2.4 | خرید مواد مصرفی مورد نیاز | 408d | 2020-06-10 A | 2021-07-22 | 77SS+5d | 6% | 383d | 92d | finish no earlier than 2021-07-22 | 99/3/21 | 100/4/31 |
| 79 | 2.3.3 | **نصب و راه اندازی تجهیزات** | 383d | 2020-07-05 A | 2021-07-22 |  | 6% | 358.64d | 92d |  | 99/4/15 | 100/4/31 |
| 80 | 2.3.3.1 | نصب تجهیزات خریداری شده | 5d | 2020-07-05 A | 2020-07-09 A | 76 | 100% |  |  |  | 99/4/15 | 99/4/19 |
| 81 | 2.3.3.2 | تکمیل لوله کشی ها و تاسیسات زیربنایی در صورت نیاز | 5d | 2020-07-10 A | 2020-07-14 A | 80 | 100% |  |  |  | 99/4/20 | 99/4/24 |
| 82 | 2.3.3.3 | تطبیق تجهیزات با طراحی های انجام شده و راه اندازی سرد واحد | 5d | 2020-07-10 A | 2020-07-14 A | 80 | 100% |  |  |  | 99/4/20 | 99/4/24 |
| 83 | 2.3.3.4 | رفع اشکالات احتمالی | 5d | 2020-07-10 A | 2020-07-14 A | 82SS | 100% |  |  |  | 99/4/20 | 99/4/24 |
| 84 | 2.3.3.5 | راه اندازی گرم سیستم و رفع اشکالات | 373d | 2020-07-15 A | 2021-07-22 | 81, 83 | 1% | 368d | 92d | finish no earlier than 2021-07-22 | 99/4/25 | 100/4/31 |
| 85 | 2.3.4 | **تولید نیمه صنعتی** | 368d | 2020-07-20 A | 2021-07-22 |  | 36% | 234.34d | 92d |  | 99/4/30 | 100/4/31 |
| 86 | 2.3.4.1 | تولید محصول در مقیاس پایلوت براساس اعلام نیاز مناطق عملیاتی | 60d | 2020-07-20 A | 2020-09-17 A | 78, 84 | 100% |  |  |  | 99/4/30 | 99/6/27 |
| 87 | 2.3.4.2 | انجام تست میدانی و دریافت تأییدیه از مناطق عملیاتی | 60d | 2020-08-19 A | 2020-10-17 A | 86SS+30d | 100% |  |  |  | 99/5/29 | 99/7/26 |
| 88 | 2.3.4.3 | گزارش نهایی | 293d | 2020-10-03 A | 2021-07-22 | 87SS+45d | 10% | 263d | 92d | finish no earlier than 2021-07-22 | 99/7/12 | 100/4/31 |
| 89 | 3 | **کسب دانش فنی و تولید ماده ضد خوردگی محلول در نفت -سه فازی** | 623d | 2019-10-23 A | 2021-07-22 |  | 20% | 499.79d | 92d |  | 98/8/1 | 100/4/31 |
| 90 | 3.1 | **فاز مطالعاتی** | 105d | 2019-10-23 A | 2020-02-04 A |  | 100% |  |  |  | 98/8/1 | 98/11/15 |
| 91 | 3.1.1 | **جمع آوری اطلاعات** | 30d | 2019-10-23 A | 2019-11-21 A |  | 100% |  |  |  | 98/8/1 | 98/8/30 |
| 92 | 3.1.1.1 | مطالعات کتابخانه ای | 30d | 2019-10-23 A | 2019-11-21 A |  | 100% |  |  |  | 98/8/1 | 98/8/30 |
| 93 | 3.1.1.2 | جمع آوری سوابق اجرای طرح | 30d | 2019-10-23 A | 2019-11-21 A | 92SS | 100% |  |  |  | 98/8/1 | 98/8/30 |
| 94 | 3.1.2 | **تکمیل مطالعات** | 75d | 2019-11-22 A | 2020-02-04 A |  | 100% |  |  |  | 98/9/1 | 98/11/15 |
| 95 | 3.1.2.1 | بررسی اطلاعات و استخراج روش های مناسب سنتز مواد | 60d | 2019-11-22 A | 2020-01-20 A | 93 | 100% |  |  |  | 98/9/1 | 98/10/30 |
| 96 | 3.1.2.2 | بررسی استانداردها و روشهای شناسایی و تأیید مواد | 60d | 2019-11-22 A | 2020-01-20 A | 95SS | 100% |  |  |  | 98/9/1 | 98/10/30 |
| 97 | 3.1.2.3 | تهیه گزارش فاز مطالعاتی | 15d | 2020-01-21 A | 2020-02-04 A | 96 | 100% |  |  |  | 98/11/1 | 98/11/15 |

| ID | WBS | Task | Duration | Start | Finish | Predecessors | Complete | Remaining | Total slack | Free slack | Constraint | شروع شمسی | پایان شمسی |
| --- | --- | --- | --- | --- | --- | --- | --- | --- | --- | --- | --- | --- | --- |
| 98 | 3.2 | **فاز آزمایشگاهی** | 75d | 2020-02-05 A | 2020-05-05 A |  | 100% |  |  |  |  | 98/11/16 | 99/2/16 |
| 99 | 3.2.1 | **طراحی آزمایشها** | 15d | 2020-02-05 A | 2020-02-19 A |  | 100% |  |  |  |  | 98/11/16 | 98/11/30 |
| 100 | 3.2.1.1 | استفاده از نرم افزارهاي مرتبط جهت برنامه ريزي آزمایشها | 7d | 2020-02-05 A | 2020-02-11 A | 97 | 100% |  |  |  |  | 98/11/16 | 98/11/22 |
| 101 | 3.2.1.2 | تدوين دستور كار تهيه آزمايشگاهي | 8d | 2020-02-12 A | 2020-02-19 A | 100 | 100% |  |  |  |  | 98/11/23 | 98/11/30 |
| 102 | 3.2.2 | **خرید مواد و تجهیزات** | 30d | 2020-02-20 A | 2020-04-05 A |  | 100% |  |  |  |  | 98/12/1 | 99/1/17 |
| 103 | 3.2.2.1 | استعلام قیمت مواد | 15d | 2020-02-20 A | 2020-03-05 A | 101 | 100% |  |  |  |  | 98/12/1 | 98/12/15 |
| 104 | 3.2.2.2 | سفارش خرید مواد | 25d | 2020-02-25 A | 2020-04-05 A | 103SS+5d | 100% |  |  |  |  | 98/12/6 | 99/1/17 |
| 105 | 3.2.2.3 | استعلام خرید تجهیزات | 15d | 2020-02-20 A | 2020-03-05 A | 103SS | 100% |  |  |  |  | 98/12/1 | 98/12/15 |
| 106 | 3.2.2.4 | خرید تجهیزات سنتز آزمایشگاهی | 25d | 2020-02-25 A | 2020-04-05 A | 105SS+5d | 100% |  |  |  |  | 98/12/6 | 99/1/17 |
| 107 | 3.2.3 | **سنتز نمونه های آزمایشگاهی** | 60d | 2020-02-20 A | 2020-05-05 A |  | 100% |  |  |  |  | 98/12/1 | 99/2/16 |
| 108 | 3.2.3.1 | سنتز نمونه ها بر اساس طراحی های انجام شده | 15d | 2020-02-20 A | 2020-03-05 A | 101 | 100% |  |  |  |  | 98/12/1 | 98/12/15 |
| 109 | 3.2.3.2 | انجام آزمونهای تأییدیه نمونه ها | 15d | 2020-02-20 A | 2020-03-05 A | 108SS | 100% |  |  |  |  | 98/12/1 | 98/12/15 |
| 110 | 3.2.3.3 | سنتز نمونه های بهینه | 20d | 2020-03-06 A | 2020-04-10 A | 109 | 100% |  |  |  |  | 98/12/16 | 99/1/22 |
| 111 | 3.2.3.4 | دریافت تأییدیه کیفیت از آزمایشگاه مرجع | 20d | 2020-03-06 A | 2020-04-10 A | 110SS | 100% |  |  |  |  | 98/12/16 | 99/1/22 |
| 112 | 3.2.3.5 | تهیه گزارش فاز آزمایشگاهی | 30d | 2020-04-06 A | 2020-05-05 A | 111SS+15d | 100% |  |  |  |  | 99/1/18 | 99/2/16 |
| 113 | 3.3 | **فاز نیمه صنعتی** | 443d | 2020-05-06 A | 2021-07-22 |  | 9% | 401.47d | 92d |  |  | 99/2/17 | 100/4/31 |
| 114 | 3.3.1 | **طراحی خط تولید بر اساس تجهیزات موجود** | 443d | 2020-05-06 A | 2021-07-22 |  | 4% | 424.01d | 92d |  |  | 99/2/17 | 100/4/31 |
| 115 | 3.3.1.1 | طراحی پایه | 15d | 2020-05-06 A | 2020-05-20 A | 112 | 100% |  |  |  |  | 99/2/17 | 99/2/31 |
| 116 | 3.3.1.2 | طراحی تفضیلی | 428d | 2020-05-21 A | 2021-07-22 | 115 | 4% | 413d | 92d | 0d | finish no earlier than 2021-07-22 | 99/3/1 | 100/4/31 |
| 117 | 3.3.1.3 | جانمایی تجهیزات | 420d | 2020-05-29 A | 2021-07-22 | 116SS+8d | 2% | 413d | 92d |  | finish no earlier than 2021-07-22 | 99/3/9 | 100/4/31 |
| 118 | 3.3.2 | **تهیه و ساخت کلیه تجهیزات و مواد مصرفی** | 413d | 2020-06-05 A | 2021-07-22 |  | 8% | 379.23d | 92d |  |  | 99/3/16 | 100/4/31 |
| 119 | 3.3.2.1 | استعلام قیمت تجهیزات مورد نیاز | 10d | 2020-06-05 A | 2020-06-14 A | 117 | 100% |  |  |  |  | 99/3/16 | 99/3/25 |
| 120 | 3.3.2.2 | خرید یا سفارش ساخت تجهیزات | 25d | 2020-06-10 A | 2020-07-04 A | 119SS+5d | 100% |  |  |  |  | 99/3/21 | 99/4/14 |
| 121 | 3.3.2.3 | استعلام قیمت مواد مصرفی جهت تولید نیمه صنعتی | 413d | 2020-06-05 A | 2021-07-22 | 119SS | 2% | 403d | 92d | 0d | finish no earlier than 2021-07-22 | 99/3/16 | 100/4/31 |
| 122 | 3.3.2.4 | خرید مواد مصرفی مورد نیاز | 408d | 2020-06-10 A | 2021-07-22 | 121SS+5d | 6% | 383d | 92d |  | finish no earlier than 2021-07-22 | 99/3/21 | 100/4/31 |

| ID | WBS | Task | Duration | Start | Finish | Predecessors | Complete | Remaining | Total slack | Free slack | Constraint | شروع شمسی | پایان شمسی |
| --- | --- | --- | --- | --- | --- | --- | --- | --- | --- | --- | --- | --- | --- |
| 123 | 3.3.3 | **نصب و راه اندازی تجهیزات** | 383d | 2020-07-05 A | 2021-07-22 |  | 2% | 374.59d | 92d |  |  | 99/4/15 | 100/4/31 |
| 124 | 3.3.3.1 | نصب تجهیزات خریداری شده | 5d | 2020-07-05 A | 2020-07-09 A | 120 | 100% |  |  |  |  | 99/4/15 | 99/4/19 |
| 125 | 3.3.3.2 | تکمیل لوله کشی ها و تاسیسات زیربنایی در صورت نیاز | 5d | 2020-07-10 A | 2020-07-14 A | 124 | 100% |  |  |  |  | 99/4/20 | 99/4/24 |
| 126 | 3.3.3.3 | تطبیق تجهیزات با طراحی های انجام شده و راه اندازی سرد واحد | 378d | 2020-07-10 A | 2021-07-22 | 124 | 1% | 373d | 92d | 0d | finish no earlier than 2021-07-22 | 99/4/20 | 100/4/31 |
| 127 | 3.3.3.4 | رفع اشکالات احتمالی | 378d | 2020-07-10 A | 2021-07-22 | 126SS | 1% | 373d | 92d | 5d | finish no earlier than 2021-07-22 | 99/4/20 | 100/4/31 |
| 128 | 3.3.3.5 | راه اندازی گرم سیستم و رفع اشکالات | 373d | 2020-07-15 A | 2021-07-22 | 125, 127SS | 1% | 368d | 92d |  | finish no earlier than 2021-07-22 | 99/4/25 | 100/4/31 |
| 129 | 3.3.4 | **تولید نیمه صنعتی** | 105d | 2020-07-20 A | 2020-11-01 A |  | 100% |  |  |  |  | 99/4/30 | 99/8/11 |
| 130 | 3.3.4.1 | تولید محصول در مقیاس پایلوت براساس اعلام نیاز مناطق عملیاتی | 60d | 2020-07-20 A | 2020-09-17 A | 122, 128 | 100% |  |  |  |  | 99/4/30 | 99/6/27 |
| 131 | 3.3.4.2 | انجام تست میدانی و دریافت تأییدیه از مناطق عملیاتی | 60d | 2020-08-19 A | 2020-10-17 A | 130SS+30d | 100% |  |  |  |  | 99/5/29 | 99/7/26 |
| 132 | 3.3.4.3 | گزارش نهایی | 30d | 2020-10-03 A | 2020-11-01 A | 131SS+45d | 100% |  |  |  |  | 99/7/12 | 99/8/11 |
| 133 | 4 | **کسب دانش فنی و تولید ماده ضد کف** | 360d | 2019-10-23 A | 2020-11-01 A |  | 100% |  |  |  |  | 98/8/1 | 99/8/11 |
| 134 | 4.1 | **فاز مطالعاتی** | 105d | 2019-10-23 A | 2020-02-04 A |  | 100% |  |  |  |  | 98/8/1 | 98/11/15 |
| 135 | 4.1.1 | **جمع آوری اطلاعات** | 30d | 2019-10-23 A | 2019-11-21 A |  | 100% |  |  |  |  | 98/8/1 | 98/8/30 |
| 136 | 4.1.1.1 | مطالعات کتابخانه ای | 30d | 2019-10-23 A | 2019-11-21 A |  | 100% |  |  |  |  | 98/8/1 | 98/8/30 |
| 137 | 4.1.1.2 | جمع آوری سوابق اجرای طرح | 30d | 2019-10-23 A | 2019-11-21 A | 136SS | 100% |  |  |  |  | 98/8/1 | 98/8/30 |
| 138 | 4.1.2 | **تکمیل مطالعات** | 75d | 2019-11-22 A | 2020-02-04 A |  | 100% |  |  |  |  | 98/9/1 | 98/11/15 |
| 139 | 4.1.2.1 | بررسی اطلاعات و استخراج روش های مناسب سنتز مواد | 60d | 2019-11-22 A | 2020-01-20 A | 137 | 100% |  |  |  |  | 98/9/1 | 98/10/30 |
| 140 | 4.1.2.2 | بررسی استانداردها و روشهای شناسایی و تأیید مواد | 60d | 2019-11-22 A | 2020-01-20 A | 139SS | 100% |  |  |  |  | 98/9/1 | 98/10/30 |
| 141 | 4.1.2.3 | تهیه گزارش فاز مطالعاتی | 15d | 2020-01-21 A | 2020-02-04 A | 140 | 100% |  |  |  |  | 98/11/1 | 98/11/15 |
| 142 | 4.2 | **فاز آزمایشگاهی** | 75d | 2020-02-05 A | 2020-05-05 A |  | 100% |  |  |  |  | 98/11/16 | 99/2/16 |
| 143 | 4.2.1 | **طراحی آزمایشها** | 15d | 2020-02-05 A | 2020-02-19 A |  | 100% |  |  |  |  | 98/11/16 | 98/11/30 |
| 144 | 4.2.1.1 | استفاده از نرم افزارهاي مرتبط جهت برنامه ريزي آزمایشها | 7d | 2020-02-05 A | 2020-02-11 A | 141 | 100% |  |  |  |  | 98/11/16 | 98/11/22 |
| 145 | 4.2.1.2 | تدوين دستور كار تهيه آزمايشگاهي | 8d | 2020-02-12 A | 2020-02-19 A | 144 | 100% |  |  |  |  | 98/11/23 | 98/11/30 |
| 146 | 4.2.2 | **خرید مواد و تجهیزات** | 30d | 2020-02-20 A | 2020-04-05 A |  | 100% |  |  |  |  | 98/12/1 | 99/1/17 |
| 147 | 4.2.2.1 | استعلام قیمت مواد | 15d | 2020-02-20 A | 2020-03-05 A | 145 | 100% |  |  |  |  | 98/12/1 | 98/12/15 |
| 148 | 4.2.2.2 | سفارش خرید مواد | 25d | 2020-02-25 A | 2020-04-05 A | 147SS+5d | 100% |  |  |  |  | 98/12/6 | 99/1/17 |
| 149 | 4.2.2.3 | استعلام خرید تجهیزات | 15d | 2020-02-20 A | 2020-03-05 A | 147SS | 100% |  |  |  |  | 98/12/1 | 98/12/15 |
| 150 | 4.2.2.4 | خرید تجهیزات سنتز آزمایشگاهی | 25d | 2020-02-25 A | 2020-04-05 A | 149SS+5d | 100% |  |  |  |  | 98/12/6 | 99/1/17 |

| ID | WBS | Task | Duration | Start | Finish | Predecessors | Complete | شروع شمسی | پایان شمسی |
| --- | --- | --- | --- | --- | --- | --- | --- | --- | --- |
| 151 | 4.2.3 | **سنتز نمونه های آزمایشگاهی** | 60d | 2020-02-20 A | 2020-05-05 A |  | 100% | 98/12/1 | 99/2/16 |
| 152 | 4.2.3.1 | سنتز نمونه ها بر اساس طراحی های انجام شده | 15d | 2020-02-20 A | 2020-03-05 A | 145 | 100% | 98/12/1 | 98/12/15 |
| 153 | 4.2.3.2 | انجام آزمونهای تأییدیه نمونه ها | 15d | 2020-02-20 A | 2020-03-05 A | 152SS | 100% | 98/12/1 | 98/12/15 |
| 154 | 4.2.3.3 | سنتز نمونه های بهینه | 20d | 2020-03-06 A | 2020-04-10 A | 153 | 100% | 98/12/16 | 99/1/22 |
| 155 | 4.2.3.4 | دریافت تأییدیه کیفیت از آزمایشگاه مرجع | 20d | 2020-03-06 A | 2020-04-10 A | 154SS | 100% | 98/12/16 | 99/1/22 |
| 156 | 4.2.3.5 | تهیه گزارش فاز آزمایشگاهی | 30d | 2020-04-06 A | 2020-05-05 A | 155SS+15d | 100% | 99/1/18 | 99/2/16 |
| 157 | 4.3 | **فاز نیمه صنعتی** | 180d | 2020-05-06 A | 2020-11-01 A |  | 100% | 99/2/17 | 99/8/11 |
| 158 | 4.3.1 | **طراحی خط تولید بر اساس تجهیزات موجود** | 30d | 2020-05-06 A | 2020-06-04 A |  | 100% | 99/2/17 | 99/3/15 |
| 159 | 4.3.1.1 | طراحی پایه | 15d | 2020-05-06 A | 2020-05-20 A | 156 | 100% | 99/2/17 | 99/2/31 |
| 160 | 4.3.1.2 | طراحی تفضیلی | 15d | 2020-05-21 A | 2020-06-04 A | 159 | 100% | 99/3/1 | 99/3/15 |
| 161 | 4.3.1.3 | جانمایی تجهیزات | 7d | 2020-05-29 A | 2020-06-04 A | 160SS+8d | 100% | 99/3/9 | 99/3/15 |
| 162 | 4.3.2 | **تهیه و ساخت کلیه تجهیزات و مواد مصرفی** | 30d | 2020-06-05 A | 2020-07-04 A |  | 100% | 99/3/16 | 99/4/14 |
| 163 | 4.3.2.1 | استعلام قیمت تجهیزات مورد نیاز | 10d | 2020-06-05 A | 2020-06-14 A | 161 | 100% | 99/3/16 | 99/3/25 |
| 164 | 4.3.2.2 | خرید یا سفارش ساخت تجهیزات | 25d | 2020-06-10 A | 2020-07-04 A | 163SS+5d | 100% | 99/3/21 | 99/4/14 |
| 165 | 4.3.2.3 | استعلام قیمت مواد مصرفی جهت تولید نیمه صنعتی | 10d | 2020-06-05 A | 2020-06-14 A | 163SS | 100% | 99/3/16 | 99/3/25 |
| 166 | 4.3.2.4 | خرید مواد مصرفی مورد نیاز | 25d | 2020-06-10 A | 2020-07-04 A | 165SS+5d | 100% | 99/3/21 | 99/4/14 |
| 167 | 4.3.3 | **نصب و راه اندازی تجهیزات** | 15d | 2020-07-05 A | 2020-07-19 A |  | 100% | 99/4/15 | 99/4/29 |
| 168 | 4.3.3.1 | نصب تجهیزات خریداری شده | 5d | 2020-07-05 A | 2020-07-09 A | 164 | 100% | 99/4/15 | 99/4/19 |
| 169 | 4.3.3.2 | تکمیل لوله کشی ها و تاسیسات زیربنایی در صورت نیاز | 5d | 2020-07-10 A | 2020-07-14 A | 168 | 100% | 99/4/20 | 99/4/24 |
| 170 | 4.3.3.3 | تطبیق تجهیزات با طراحی های انجام شده و راه اندازی سرد واحد | 5d | 2020-07-10 A | 2020-07-14 A | 168 | 100% | 99/4/20 | 99/4/24 |
| 171 | 4.3.3.4 | رفع اشکالات احتمالی | 5d | 2020-07-10 A | 2020-07-14 A | 170SS | 100% | 99/4/20 | 99/4/24 |
| 172 | 4.3.3.5 | راه اندازی گرم سیستم و رفع اشکالات | 5d | 2020-07-15 A | 2020-07-19 A | 169, 171 | 100% | 99/4/25 | 99/4/29 |
| 173 | 4.3.4 | **تولید نیمه صنعتی** | 105d | 2020-07-20 A | 2020-11-01 A |  | 100% | 99/4/30 | 99/8/11 |
| 174 | 4.3.4.1 | تولید محصول در مقیاس پایلوت براساس اعلام نیاز مناطق عملیاتی | 60d | 2020-07-20 A | 2020-09-17 A | 166, 172 | 100% | 99/4/30 | 99/6/27 |
| 175 | 4.3.4.2 | انجام تست میدانی و دریافت تأییدیه از مناطق عملیاتی | 60d | 2020-08-19 A | 2020-10-17 A | 174SS+30d | 100% | 99/5/29 | 99/7/26 |
| 176 | 4.3.4.3 | گزارش نهایی | 30d | 2020-10-03 A | 2020-11-01 A | 175SS+45d | 100% | 99/7/12 | 99/8/11 |

| ID | WBS | Task | Duration | Start | Finish | Predecessors | Complete | Remaining | Total slack | شروع شمسی | پایان شمسی |
| --- | --- | --- | --- | --- | --- | --- | --- | --- | --- | --- | --- |
| 177 | 5 | **کسب دانش فنی و تولید ماده بیوساید 1** | 654d | 2019-10-23 A | 2021-08-22 |  | 21% | 517.13d | 61d | 98/8/1 | 100/5/31 |
| 178 | 5.1 | **فاز مطالعاتی** | 105d | 2019-10-23 A | 2020-02-04 A |  | 100% |  |  | 98/8/1 | 98/11/15 |
| 179 | 5.1.1 | **جمع آوری اطلاعات** | 30d | 2019-10-23 A | 2019-11-21 A |  | 100% |  |  | 98/8/1 | 98/8/30 |
| 180 | 5.1.1.1 | مطالعات کتابخانه ای | 30d | 2019-10-23 A | 2019-11-21 A |  | 100% |  |  | 98/8/1 | 98/8/30 |
| 181 | 5.1.1.2 | جمع آوری سوابق اجرای طرح | 30d | 2019-10-23 A | 2019-11-21 A | 180SS | 100% |  |  | 98/8/1 | 98/8/30 |
| 182 | 5.1.2 | **تکمیل مطالعات** | 75d | 2019-11-22 A | 2020-02-04 A |  | 100% |  |  | 98/9/1 | 98/11/15 |
| 183 | 5.1.2.1 | بررسی اطلاعات و استخراج روش های مناسب سنتز مواد | 60d | 2019-11-22 A | 2020-01-20 A | 181 | 100% |  |  | 98/9/1 | 98/10/30 |
| 184 | 5.1.2.2 | بررسی استانداردها و روشهای شناسایی و تأیید مواد | 60d | 2019-11-22 A | 2020-01-20 A | 183SS | 100% |  |  | 98/9/1 | 98/10/30 |
| 185 | 5.1.2.3 | تهیه گزارش فاز مطالعاتی | 15d | 2020-01-21 A | 2020-02-04 A | 184 | 100% |  |  | 98/11/1 | 98/11/15 |
| 186 | 5.2 | **فاز آزمایشگاهی** | 75d | 2020-02-05 A | 2020-05-05 A |  | 100% |  |  | 98/11/16 | 99/2/16 |
| 187 | 5.2.1 | **طراحی آزمایشها** | 15d | 2020-02-05 A | 2020-02-19 A |  | 100% |  |  | 98/11/16 | 98/11/30 |
| 188 | 5.2.1.1 | استفاده از نرم افزارهاي مرتبط جهت برنامه ريزي آزمایشها | 7d | 2020-02-05 A | 2020-02-11 A | 185 | 100% |  |  | 98/11/16 | 98/11/22 |
| 189 | 5.2.1.2 | تدوين دستور كار تهيه آزمايشگاهي | 8d | 2020-02-12 A | 2020-02-19 A | 188 | 100% |  |  | 98/11/23 | 98/11/30 |
| 190 | 5.2.2 | **خرید مواد و تجهیزات** | 30d | 2020-02-20 A | 2020-04-05 A |  | 100% |  |  | 98/12/1 | 99/1/17 |
| 191 | 5.2.2.1 | استعلام قیمت مواد | 15d | 2020-02-20 A | 2020-03-05 A | 189 | 100% |  |  | 98/12/1 | 98/12/15 |
| 192 | 5.2.2.2 | سفارش خرید مواد | 25d | 2020-02-25 A | 2020-04-05 A | 191SS+5d | 100% |  |  | 98/12/6 | 99/1/17 |
| 193 | 5.2.2.3 | استعلام خرید تجهیزات | 15d | 2020-02-20 A | 2020-03-05 A | 191SS | 100% |  |  | 98/12/1 | 98/12/15 |
| 194 | 5.2.2.4 | خرید تجهیزات سنتز آزمایشگاهی | 25d | 2020-02-25 A | 2020-04-05 A | 193SS+5d | 100% |  |  | 98/12/6 | 99/1/17 |
| 195 | 5.2.3 | **سنتز نمونه های آزمایشگاهی** | 60d | 2020-02-20 A | 2020-05-05 A |  | 100% |  |  | 98/12/1 | 99/2/16 |
| 196 | 5.2.3.1 | سنتز نمونه ها بر اساس طراحی های انجام شده | 15d | 2020-02-20 A | 2020-03-05 A | 189 | 100% |  |  | 98/12/1 | 98/12/15 |
| 197 | 5.2.3.2 | انجام آزمونهای تأییدیه نمونه ها | 15d | 2020-02-20 A | 2020-03-05 A | 196SS | 100% |  |  | 98/12/1 | 98/12/15 |
| 198 | 5.2.3.3 | سنتز نمونه های بهینه | 20d | 2020-03-06 A | 2020-04-10 A | 197 | 100% |  |  | 98/12/16 | 99/1/22 |
| 199 | 5.2.3.4 | دریافت تأییدیه کیفیت از آزمایشگاه مرجع | 20d | 2020-03-06 A | 2020-04-10 A | 198SS | 100% |  |  | 98/12/16 | 99/1/22 |
| 200 | 5.2.3.5 | تهیه گزارش فاز آزمایشگاهی | 30d | 2020-04-06 A | 2020-05-05 A | 199SS+15d | 100% |  |  | 99/1/18 | 99/2/16 |

| ID | WBS | Task | Duration | Start | Finish | Predecessors | Complete | Remaining | Total slack | Free slack | Constraint | شروع شمسی | پایان شمسی |
| --- | --- | --- | --- | --- | --- | --- | --- | --- | --- | --- | --- | --- | --- |
| 201 | 5.3 | **فاز نیمه صنعتی** | 474d | 2020-05-06 A | 2021-08-22 |  | 10% | 426.62d | 61d |  |  | 99/2/17 | 100/5/31 |
| 202 | 5.3.1 | **طراحی خط تولید بر اساس تجهیزات موجود** | 474d | 2020-05-06 A | 2021-08-22 |  | 4% | 455.04d | 61d |  |  | 99/2/17 | 100/5/31 |
| 203 | 5.3.1.1 | طراحی پایه | 15d | 2020-05-06 A | 2020-05-20 A | 200 | 100% |  |  |  |  | 99/2/17 | 99/2/31 |
| 204 | 5.3.1.2 | طراحی تفضیلی | 459d | 2020-05-21 A | 2021-08-22 | 203 | 3% | 444d | 61d | 0d | finish no earlier than 2021-08-22 | 99/3/1 | 100/5/31 |
| 205 | 5.3.1.3 | جانمایی تجهیزات | 451d | 2020-05-29 A | 2021-08-22 | 204SS+8d | 2% | 444d | 61d |  | finish no earlier than 2021-08-22 | 99/3/9 | 100/5/31 |
| 206 | 5.3.2 | **تهیه و ساخت کلیه تجهیزات و مواد مصرفی** | 444d | 2020-06-05 A | 2021-08-22 |  | 8% | 410.14d | 61d |  |  | 99/3/16 | 100/5/31 |
| 207 | 5.3.2.1 | استعلام قیمت تجهیزات مورد نیاز | 10d | 2020-06-05 A | 2020-06-14 A | 205 | 100% |  |  |  |  | 99/3/16 | 99/3/25 |
| 208 | 5.3.2.2 | خرید یا سفارش ساخت تجهیزات | 25d | 2020-06-10 A | 2020-07-04 A | 207SS+5d | 100% |  |  |  |  | 99/3/21 | 99/4/14 |
| 209 | 5.3.2.3 | استعلام قیمت مواد مصرفی جهت تولید نیمه صنعتی | 444d | 2020-06-05 A | 2021-08-22 | 207SS | 2% | 434d | 61d | 0d | finish no earlier than 2021-08-22 | 99/3/16 | 100/5/31 |
| 210 | 5.3.2.4 | خرید مواد مصرفی مورد نیاز | 439d | 2020-06-10 A | 2021-08-22 | 209SS+5d | 6% | 414d | 61d |  | finish no earlier than 2021-08-22 | 99/3/21 | 100/5/31 |
| 211 | 5.3.3 | **نصب و راه اندازی تجهیزات** | 414d | 2020-07-05 A | 2021-08-22 |  | 3% | 401.5d | 61d |  |  | 99/4/15 | 100/5/31 |
| 212 | 5.3.3.1 | نصب تجهیزات خریداری شده | 5d | 2020-07-05 A | 2020-07-09 A | 208 | 100% |  |  |  |  | 99/4/15 | 99/4/19 |
| 213 | 5.3.3.2 | تکمیل لوله کشی ها و تاسیسات زیربنایی در صورت نیاز | 5d | 2020-07-10 A | 2020-07-14 A | 212 | 100% |  |  |  |  | 99/4/20 | 99/4/24 |
| 214 | 5.3.3.3 | تطبیق تجهیزات با طراحی های انجام شده و راه اندازی سرد واحد | 5d | 2020-07-10 A | 2020-07-14 A | 212 | 100% |  |  |  |  | 99/4/20 | 99/4/24 |
| 215 | 5.3.3.4 | رفع اشکالات احتمالی | 409d | 2020-07-10 A | 2021-08-22 | 214SS | 1% | 404d | 61d | 5d | finish no earlier than 2021-08-22 | 99/4/20 | 100/5/31 |
| 216 | 5.3.3.5 | راه اندازی گرم سیستم و رفع اشکالات | 404d | 2020-07-15 A | 2021-08-22 | 213, 215SS | 1% | 399d | 61d |  | finish no earlier than 2021-08-22 | 99/4/25 | 100/5/31 |
| 217 | 5.3.4 | **تولید نیمه صنعتی** | 105d | 2020-07-20 A | 2020-11-01 A |  | 100% |  |  |  |  | 99/4/30 | 99/8/11 |
| 218 | 5.3.4.1 | تولید محصول در مقیاس پایلوت براساس اعلام نیاز مناطق عملیاتی | 60d | 2020-07-20 A | 2020-09-17 A | 210, 216 | 100% |  |  |  |  | 99/4/30 | 99/6/27 |
| 219 | 5.3.4.2 | انجام تست میدانی و دریافت تأییدیه از مناطق عملیاتی | 60d | 2020-08-19 A | 2020-10-17 A | 218SS+30d | 100% |  |  |  |  | 99/5/29 | 99/7/26 |
| 220 | 5.3.4.3 | گزارش نهایی | 30d | 2020-10-03 A | 2020-11-01 A | 219SS+45d | 100% |  |  |  |  | 99/7/12 | 99/8/11 |
| 221 | 6 | **کسب دانش فنی و تولید ماده بیوساید 2** | 654d | 2019-10-23 A | 2021-08-22 |  | 18% | 534.48d | 61d |  |  | 98/8/1 | 100/5/31 |
| 222 | 6.1 | **فاز مطالعاتی** | 105d | 2019-10-23 A | 2020-02-04 A |  | 100% |  |  |  |  | 98/8/1 | 98/11/15 |
| 223 | 6.1.1 | **جمع آوری اطلاعات** | 30d | 2019-10-23 A | 2019-11-21 A |  | 100% |  |  |  |  | 98/8/1 | 98/8/30 |
| 224 | 6.1.1.1 | مطالعات کتابخانه ای | 30d | 2019-10-23 A | 2019-11-21 A |  | 100% |  |  |  |  | 98/8/1 | 98/8/30 |
| 225 | 6.1.1.2 | جمع آوری سوابق اجرای طرح | 30d | 2019-10-23 A | 2019-11-21 A | 224SS | 100% |  |  |  |  | 98/8/1 | 98/8/30 |

| ID | WBS | Task | Duration | Start | Finish | Predecessors | Complete | Remaining | Total slack | Free slack | Constraint | شروع شمسی | پایان شمسی |
| --- | --- | --- | --- | --- | --- | --- | --- | --- | --- | --- | --- | --- | --- |
| 226 | 6.1.2 | **تکمیل مطالعات** | 75d | 2019-11-22 A | 2020-02-04 A |  | 100% |  |  |  |  | 98/9/1 | 98/11/15 |
| 227 | 6.1.2.1 | بررسی اطلاعات و استخراج روش های مناسب سنتز مواد | 60d | 2019-11-22 A | 2020-01-20 A | 225 | 100% |  |  |  |  | 98/9/1 | 98/10/30 |
| 228 | 6.1.2.2 | بررسی استانداردها و روشهای شناسایی و تأیید مواد | 60d | 2019-11-22 A | 2020-01-20 A | 227SS | 100% |  |  |  |  | 98/9/1 | 98/10/30 |
| 229 | 6.1.2.3 | تهیه گزارش فاز مطالعاتی | 15d | 2020-01-21 A | 2020-02-04 A | 228 | 100% |  |  |  |  | 98/11/1 | 98/11/15 |
| 230 | 6.2 | **فاز آزمایشگاهی** | 75d | 2020-02-05 A | 2020-05-05 A |  | 100% |  |  |  |  | 98/11/16 | 99/2/16 |
| 231 | 6.2.1 | **طراحی آزمایشها** | 15d | 2020-02-05 A | 2020-02-19 A |  | 100% |  |  |  |  | 98/11/16 | 98/11/30 |
| 232 | 6.2.1.1 | استفاده از نرم افزارهاي مرتبط جهت برنامه ريزي آزمایشها | 7d | 2020-02-05 A | 2020-02-11 A | 229 | 100% |  |  |  |  | 98/11/16 | 98/11/22 |
| 233 | 6.2.1.2 | تدوين دستور كار تهيه آزمايشگاهي | 8d | 2020-02-12 A | 2020-02-19 A | 232 | 100% |  |  |  |  | 98/11/23 | 98/11/30 |
| 234 | 6.2.2 | **خرید مواد و تجهیزات** | 30d | 2020-02-20 A | 2020-04-05 A |  | 100% |  |  |  |  | 98/12/1 | 99/1/17 |
| 235 | 6.2.2.1 | استعلام قیمت مواد | 15d | 2020-02-20 A | 2020-03-05 A | 233 | 100% |  |  |  |  | 98/12/1 | 98/12/15 |
| 236 | 6.2.2.2 | سفارش خرید مواد | 25d | 2020-02-25 A | 2020-04-05 A | 235SS+5d | 100% |  |  |  |  | 98/12/6 | 99/1/17 |
| 237 | 6.2.2.3 | استعلام خرید تجهیزات | 15d | 2020-02-20 A | 2020-03-05 A | 235SS | 100% |  |  |  |  | 98/12/1 | 98/12/15 |
| 238 | 6.2.2.4 | خرید تجهیزات سنتز آزمایشگاهی | 25d | 2020-02-25 A | 2020-04-05 A | 237SS+5d | 100% |  |  |  |  | 98/12/6 | 99/1/17 |
| 239 | 6.2.3 | **سنتز نمونه های آزمایشگاهی** | 60d | 2020-02-20 A | 2020-05-05 A |  | 100% |  |  |  |  | 98/12/1 | 99/2/16 |
| 240 | 6.2.3.1 | سنتز نمونه ها بر اساس طراحی های انجام شده | 15d | 2020-02-20 A | 2020-03-05 A | 233 | 100% |  |  |  |  | 98/12/1 | 98/12/15 |
| 241 | 6.2.3.2 | انجام آزمونهای تأییدیه نمونه ها | 15d | 2020-02-20 A | 2020-03-05 A | 240SS | 100% |  |  |  |  | 98/12/1 | 98/12/15 |
| 242 | 6.2.3.3 | سنتز نمونه های بهینه | 20d | 2020-03-06 A | 2020-04-10 A | 241 | 100% |  |  |  |  | 98/12/16 | 99/1/22 |
| 243 | 6.2.3.4 | دریافت تأییدیه کیفیت از آزمایشگاه مرجع | 20d | 2020-03-06 A | 2020-04-10 A | 242SS | 100% |  |  |  |  | 98/12/16 | 99/1/22 |
| 244 | 6.2.3.5 | تهیه گزارش فاز آزمایشگاهی | 30d | 2020-04-06 A | 2020-05-05 A | 243SS+15d | 100% |  |  |  |  | 99/1/18 | 99/2/16 |
| 245 | 6.3 | **فاز نیمه صنعتی** | 474d | 2020-05-06 A | 2021-08-22 |  | 8% | 435.58d | 61d |  |  | 99/2/17 | 100/5/31 |
| 246 | 6.3.1 | **طراحی خط تولید بر اساس تجهیزات موجود** | 474d | 2020-05-06 A | 2021-08-22 |  | 4% | 455.04d | 61d |  |  | 99/2/17 | 100/5/31 |
| 247 | 6.3.1.1 | طراحی پایه | 15d | 2020-05-06 A | 2020-05-20 A | 244 | 100% |  |  |  |  | 99/2/17 | 99/2/31 |
| 248 | 6.3.1.2 | طراحی تفضیلی | 459d | 2020-05-21 A | 2021-08-22 | 247 | 3% | 444d | 61d | 0d | finish no earlier than 2021-08-22 | 99/3/1 | 100/5/31 |
| 249 | 6.3.1.3 | جانمایی تجهیزات | 451d | 2020-05-29 A | 2021-08-22 | 248SS+8d | 2% | 444d | 61d |  | finish no earlier than 2021-08-22 | 99/3/9 | 100/5/31 |

| ID | WBS | Task | Duration | Start | Finish | Predecessors | Complete | Remaining | Total slack | Free slack | Constraint | شروع شمسی | پایان شمسی |
| --- | --- | --- | --- | --- | --- | --- | --- | --- | --- | --- | --- | --- | --- |
| 250 | 6.3.2 | **تهیه و ساخت کلیه تجهیزات و مواد مصرفی** | 444d | 2020-06-05 A | 2021-08-22 |  | 14% | 379.79d | 61d |  |  | 99/3/16 | 100/5/31 |
| 251 | 6.3.2.1 | استعلام قیمت تجهیزات مورد نیاز | 10d | 2020-06-05 A | 2020-06-14 A | 249 | 100% |  |  |  |  | 99/3/16 | 99/3/25 |
| 252 | 6.3.2.2 | خرید یا سفارش ساخت تجهیزات | 25d | 2020-06-10 A | 2020-07-04 A | 251SS+5d | 100% |  |  |  |  | 99/3/21 | 99/4/14 |
| 253 | 6.3.2.3 | استعلام قیمت مواد مصرفی جهت تولید نیمه صنعتی | 10d | 2020-06-05 A | 2020-06-14 A | 251SS | 100% |  |  |  |  | 99/3/16 | 99/3/25 |
| 254 | 6.3.2.4 | خرید مواد مصرفی مورد نیاز | 439d | 2020-06-10 A | 2021-08-22 | 253SS+5d | 6% | 414d | 61d | 40d | finish no earlier than 2021-08-22 | 99/3/21 | 100/5/31 |
| 255 | 6.3.3 | **نصب و راه اندازی تجهیزات** | 414d | 2020-07-05 A | 2021-08-22 |  | 2% | 405.6d | 61d |  |  | 99/4/15 | 100/5/31 |
| 256 | 6.3.3.1 | نصب تجهیزات خریداری شده | 5d | 2020-07-05 A | 2020-07-09 A | 252 | 100% |  |  |  |  | 99/4/15 | 99/4/19 |
| 257 | 6.3.3.2 | تکمیل لوله کشی ها و تاسیسات زیربنایی در صورت نیاز | 5d | 2020-07-10 A | 2020-07-14 A | 256 | 100% |  |  |  |  | 99/4/20 | 99/4/24 |
| 258 | 6.3.3.3 | تطبیق تجهیزات با طراحی های انجام شده و راه اندازی سرد واحد | 409d | 2020-07-10 A | 2021-08-22 | 256 | 1% | 404d | 61d | 0d | finish no earlier than 2021-08-22 | 99/4/20 | 100/5/31 |
| 259 | 6.3.3.4 | رفع اشکالات احتمالی | 409d | 2020-07-10 A | 2021-08-22 | 258SS | 1% | 404d | 61d | 5d | finish no earlier than 2021-08-22 | 99/4/20 | 100/5/31 |
| 260 | 6.3.3.5 | راه اندازی گرم سیستم و رفع اشکالات | 404d | 2020-07-15 A | 2021-08-22 | 257, 259SS | 1% | 399d | 61d | 5d | finish no earlier than 2021-08-22 | 99/4/25 | 100/5/31 |
| 261 | 6.3.4 | **تولید نیمه صنعتی** | 399d | 2020-07-20 A | 2021-08-22 |  | 25% | 300.26d | 61d |  |  | 99/4/30 | 100/5/31 |
| 262 | 6.3.4.1 | تولید محصول در مقیاس پایلوت براساس اعلام نیاز مناطق عملیاتی | 399d | 2020-07-20 A | 2021-08-22 | 254SS, 260SS | 15% | 339d | 61d |  | finish no earlier than 2021-08-22 | 99/4/30 | 100/5/31 |
| 263 | 6.3.4.2 | انجام تست میدانی و دریافت تأییدیه از مناطق عملیاتی | 32d | 2021-07-22 A | 2021-08-22 A | 262SS | 100% |  |  |  | finish no earlier than 2021-08-22 | 100/4/31 | 100/5/31 |
| 264 | 6.3.4.3 | گزارش نهایی | 62d | 2020-10-03 A | 2021-08-22 | 263SS | 48% | 32d | 61d |  | finish no earlier than 2021-08-22 | 99/7/12 | 100/5/31 |
| 265 | 7 | **کسب دانش فنی و تولید دمولسی فایر معکوس** | 685d | 2019-10-23 A | 2021-09-22 |  | 16% | 574.35d | 30d |  |  | 98/8/1 | 100/6/31 |
| 266 | 7.1 | **فاز مطالعاتی** | 105d | 2019-10-23 A | 2020-02-04 A |  | 100% |  |  |  |  | 98/8/1 | 98/11/15 |
| 267 | 7.1.1 | **جمع آوری اطلاعات** | 30d | 2019-10-23 A | 2019-11-21 A |  | 100% |  |  |  |  | 98/8/1 | 98/8/30 |
| 268 | 7.1.1.1 | مطالعات کتابخانه ای | 30d | 2019-10-23 A | 2019-11-21 A |  | 100% |  |  |  |  | 98/8/1 | 98/8/30 |
| 269 | 7.1.1.2 | جمع آوری سوابق اجرای طرح | 30d | 2019-10-23 A | 2019-11-21 A | 268SS | 100% |  |  |  |  | 98/8/1 | 98/8/30 |
| 270 | 7.1.2 | **تکمیل مطالعات** | 75d | 2019-11-22 A | 2020-02-04 A |  | 100% |  |  |  |  | 98/9/1 | 98/11/15 |
| 271 | 7.1.2.1 | بررسی اطلاعات و استخراج روش های مناسب سنتز مواد | 60d | 2019-11-22 A | 2020-01-20 A | 269 | 100% |  |  |  |  | 98/9/1 | 98/10/30 |
| 272 | 7.1.2.2 | بررسی استانداردها و روشهای شناسایی و تأیید مواد | 60d | 2019-11-22 A | 2020-01-20 A | 271SS | 100% |  |  |  |  | 98/9/1 | 98/10/30 |
| 273 | 7.1.2.3 | تهیه گزارش فاز مطالعاتی | 15d | 2020-01-21 A | 2020-02-04 A | 272 | 100% |  |  |  |  | 98/11/1 | 98/11/15 |

| ID | WBS | Task | Duration | Start | Finish | Predecessors | Complete | Remaining | Total slack | Free slack | Constraint | شروع شمسی | پایان شمسی |
| --- | --- | --- | --- | --- | --- | --- | --- | --- | --- | --- | --- | --- | --- |
| 274 | 7.2 | **فاز آزمایشگاهی** | 518d | 2020-02-05 A | 2021-07-22 |  | 85% | 75.44d | 92d |  |  | 98/11/16 | 100/4/31 |
| 275 | 7.2.1 | **طراحی آزمایشها** | 15d | 2020-02-05 A | 2020-02-19 A |  | 100% |  |  |  |  | 98/11/16 | 98/11/30 |
| 276 | 7.2.1.1 | استفاده از نرم افزارهاي مرتبط جهت برنامه ريزي آزمایشها | 7d | 2020-02-05 A | 2020-02-11 A | 273 | 100% |  |  |  |  | 98/11/16 | 98/11/22 |
| 277 | 7.2.1.2 | تدوين دستور كار تهيه آزمايشگاهي | 8d | 2020-02-12 A | 2020-02-19 A | 276 | 100% |  |  |  |  | 98/11/23 | 98/11/30 |
| 278 | 7.2.2 | **خرید مواد و تجهیزات** | 30d | 2020-02-20 A | 2020-04-05 A |  | 100% |  |  |  |  | 98/12/1 | 99/1/17 |
| 279 | 7.2.2.1 | استعلام قیمت مواد | 15d | 2020-02-20 A | 2020-03-05 A | 277 | 100% |  |  |  |  | 98/12/1 | 98/12/15 |
| 280 | 7.2.2.2 | سفارش خرید مواد | 25d | 2020-02-25 A | 2020-04-05 A | 279SS+5d | 100% |  |  |  |  | 98/12/6 | 99/1/17 |
| 281 | 7.2.2.3 | استعلام خرید تجهیزات | 15d | 2020-02-20 A | 2020-03-05 A | 279SS | 100% |  |  |  |  | 98/12/1 | 98/12/15 |
| 282 | 7.2.2.4 | خرید تجهیزات سنتز آزمایشگاهی | 25d | 2020-02-25 A | 2020-04-05 A | 281SS+5d | 100% |  |  |  |  | 98/12/6 | 99/1/17 |
| 283 | 7.2.3 | **سنتز نمونه های آزمایشگاهی** | 503d | 2020-02-20 A | 2021-07-22 |  | 73% | 135.95d | 92d |  |  | 98/12/1 | 100/4/31 |
| 284 | 7.2.3.1 | سنتز نمونه ها بر اساس طراحی های انجام شده | 15d | 2020-02-20 A | 2020-03-05 A | 277 | 100% |  |  |  |  | 98/12/1 | 98/12/15 |
| 285 | 7.2.3.2 | انجام آزمونهای تأییدیه نمونه ها | 15d | 2020-02-20 A | 2020-03-05 A | 284SS | 100% |  |  |  |  | 98/12/1 | 98/12/15 |
| 286 | 7.2.3.3 | سنتز نمونه های بهینه | 20d | 2020-03-06 A | 2020-04-10 A | 285 | 100% |  |  |  |  | 98/12/16 | 99/1/22 |
| 287 | 7.2.3.4 | دریافت تأییدیه کیفیت از آزمایشگاه مرجع | 31d | 2021-06-22 A | 2021-07-22 | 286SS | 3% | 30d | 92d |  | finish no earlier than 2021-07-22 | 100/4/1 | 100/4/31 |
| 288 | 7.2.3.5 | تهیه گزارش فاز آزمایشگاهی | 30d | 2020-04-06 A | 2020-05-05 A | 287SS+15d | 100% |  |  |  |  | 99/1/18 | 99/2/16 |
| 289 | 7.3 | **فاز نیمه صنعتی** | 505d | 2020-05-06 A | 2021-09-22 |  | 7% | 470.36d | 30d |  |  | 99/2/17 | 100/6/31 |
| 290 | 7.3.1 | **طراحی خط تولید بر اساس تجهیزات موجود** | 505d | 2020-05-06 A | 2021-09-22 |  | 4% | 486.07d | 30d |  |  | 99/2/17 | 100/6/31 |
| 291 | 7.3.1.1 | طراحی پایه | 15d | 2020-05-06 A | 2020-05-20 A | 288 | 100% |  |  |  |  | 99/2/17 | 99/2/31 |
| 292 | 7.3.1.2 | طراحی تفضیلی | 490d | 2020-05-21 A | 2021-09-22 | 291 | 3% | 475d | 30d | 0d | finish no earlier than 2021-09-22 | 99/3/1 | 100/6/31 |
| 293 | 7.3.1.3 | جانمایی تجهیزات | 482d | 2020-05-29 A | 2021-09-22 | 292SS+8d | 1% | 475d | 30d |  | finish no earlier than 2021-09-22 | 99/3/9 | 100/6/31 |
| 294 | 7.3.2 | **تهیه و ساخت کلیه تجهیزات و مواد مصرفی** | 475d | 2020-06-05 A | 2021-09-22 |  | 7% | 441.07d | 30d |  |  | 99/3/16 | 100/6/31 |
| 295 | 7.3.2.1 | استعلام قیمت تجهیزات مورد نیاز | 10d | 2020-06-05 A | 2020-06-14 A | 293 | 100% |  |  |  |  | 99/3/16 | 99/3/25 |
| 296 | 7.3.2.2 | خرید یا سفارش ساخت تجهیزات | 25d | 2020-06-10 A | 2020-07-04 A | 295SS+5d | 100% |  |  |  |  | 99/3/21 | 99/4/14 |
| 297 | 7.3.2.3 | استعلام قیمت مواد مصرفی جهت تولید نیمه صنعتی | 475d | 2020-06-05 A | 2021-09-22 | 295SS | 2% | 465d | 30d | 0d | finish no earlier than 2021-09-22 | 99/3/16 | 100/6/31 |
| 298 | 7.3.2.4 | خرید مواد مصرفی مورد نیاز | 470d | 2020-06-10 A | 2021-09-22 | 297SS+5d | 5% | 445d | 30d |  | finish no earlier than 2021-09-22 | 99/3/21 | 100/6/31 |

| ID | WBS | Task | Duration | Start | Finish | Predecessors | Complete | Remaining | Total slack | Free slack | Constraint | شروع شمسی | پایان شمسی |
| --- | --- | --- | --- | --- | --- | --- | --- | --- | --- | --- | --- | --- | --- |
| 299 | 7.3.3 | **نصب و راه اندازی تجهیزات** | 414d | 2020-07-05 A | 2021-08-22 |  | 2% | 405.6d | 61d |  |  | 99/4/15 | 100/5/31 |
| 300 | 7.3.3.1 | نصب تجهیزات خریداری شده | 5d | 2020-07-05 A | 2020-07-09 A | 296 | 100% |  |  |  |  | 99/4/15 | 99/4/19 |
| 301 | 7.3.3.2 | تکمیل لوله کشی ها و تاسیسات زیربنایی در صورت نیاز | 5d | 2020-07-10 A | 2020-07-14 A | 300 | 100% |  |  |  |  | 99/4/20 | 99/4/24 |
| 302 | 7.3.3.3 | تطبیق تجهیزات با طراحی های انجام شده و راه اندازی سرد واحد | 409d | 2020-07-10 A | 2021-08-22 | 300 | 1% | 404d | 61d | 0d | finish no earlier than 2021-08-22 | 99/4/20 | 100/5/31 |
| 303 | 7.3.3.4 | رفع اشکالات احتمالی | 409d | 2020-07-10 A | 2021-08-22 | 302SS | 1% | 404d | 61d | 5d | finish no earlier than 2021-08-22 | 99/4/20 | 100/5/31 |
| 304 | 7.3.3.5 | راه اندازی گرم سیستم و رفع اشکالات | 404d | 2020-07-15 A | 2021-08-22 | 301, 303SS | 1% | 399d | 61d |  | finish no earlier than 2021-08-22 | 99/4/25 | 100/5/31 |
| 305 | 7.3.4 | **تولید نیمه صنعتی** | 32d | 2021-08-22 A | 2021-09-22 |  | 98% | 0.67d | 30d |  |  | 100/5/31 | 100/6/31 |
| 306 | 7.3.4.1 | تولید محصول در مقیاس پایلوت براساس اعلام نیاز مناطق عملیاتی | 32d | 2021-08-22 A | 2021-09-22 A | 298, 304 | 100% |  |  |  |  | 100/5/31 | 100/6/31 |
| 307 | 7.3.4.2 | انجام تست میدانی و دریافت تأییدیه از مناطق عملیاتی | 32d | 2021-08-22 A | 2021-09-22 A | 306SS+30d | 100% |  |  |  |  | 100/5/31 | 100/6/31 |
| 308 | 7.3.4.3 | گزارش نهایی | 32d | 2021-08-22 A | 2021-09-22 | 307SS | 94% | 2d | 30d |  | finish no earlier than 2021-09-22 | 100/5/31 | 100/6/31 |
| 309 | 8 | **کسب دانش فنی و تولید پلی الکترولیت** | 685d | 2019-10-23 A | 2021-09-22 |  | 10% | 613.29d | 30d |  |  | 98/8/1 | 100/6/31 |
| 310 | 8.1 | **فاز مطالعاتی** | 105d | 2019-10-23 A | 2020-02-04 A |  | 100% |  |  |  |  | 98/8/1 | 98/11/15 |
| 311 | 8.1.1 | **جمع آوری اطلاعات** | 30d | 2019-10-23 A | 2019-11-21 A |  | 100% |  |  |  |  | 98/8/1 | 98/8/30 |
| 312 | 8.1.1.1 | مطالعات کتابخانه ای | 30d | 2019-10-23 A | 2019-11-21 A |  | 100% |  |  |  |  | 98/8/1 | 98/8/30 |
| 313 | 8.1.1.2 | جمع آوری سوابق اجرای طرح | 30d | 2019-10-23 A | 2019-11-21 A | 312SS | 100% |  |  |  |  | 98/8/1 | 98/8/30 |
| 314 | 8.1.2 | **تکمیل مطالعات** | 75d | 2019-11-22 A | 2020-02-04 A |  | 100% |  |  |  |  | 98/9/1 | 98/11/15 |
| 315 | 8.1.2.1 | بررسی اطلاعات و استخراج روش های مناسب سنتز مواد | 60d | 2019-11-22 A | 2020-01-20 A | 313 | 100% |  |  |  |  | 98/9/1 | 98/10/30 |
| 316 | 8.1.2.2 | بررسی استانداردها و روشهای شناسایی و تأیید مواد | 60d | 2019-11-22 A | 2020-01-20 A | 315SS | 100% |  |  |  |  | 98/9/1 | 98/10/30 |
| 317 | 8.1.2.3 | تهیه گزارش فاز مطالعاتی | 15d | 2020-01-21 A | 2020-02-04 A | 316 | 100% |  |  |  |  | 98/11/1 | 98/11/15 |
| 318 | 8.2 | **فاز آزمایشگاهی** | 518d | 2020-02-05 A | 2021-07-22 |  | 9% | 469.01d | 92d |  |  | 98/11/16 | 100/4/31 |
| 319 | 8.2.1 | **طراحی آزمایشها** | 15d | 2020-02-05 A | 2020-02-19 A |  | 100% |  |  |  |  | 98/11/16 | 98/11/30 |
| 320 | 8.2.1.1 | استفاده از نرم افزارهاي مرتبط جهت برنامه ريزي آزمایشها | 7d | 2020-02-05 A | 2020-02-11 A | 317 | 100% |  |  |  |  | 98/11/16 | 98/11/22 |
| 321 | 8.2.1.2 | تدوين دستور كار تهيه آزمايشگاهي | 8d | 2020-02-12 A | 2020-02-19 A | 320 | 100% |  |  |  |  | 98/11/23 | 98/11/30 |
| 322 | 8.2.2 | **خرید مواد و تجهیزات** | 30d | 2020-02-20 A | 2020-04-05 A |  | 100% |  |  |  |  | 98/12/1 | 99/1/17 |
| 323 | 8.2.2.1 | استعلام قیمت مواد | 15d | 2020-02-20 A | 2020-03-05 A | 321 | 100% |  |  |  |  | 98/12/1 | 98/12/15 |
| 324 | 8.2.2.2 | سفارش خرید مواد | 25d | 2020-02-25 A | 2020-04-05 A | 323SS+5d | 100% |  |  |  |  | 98/12/6 | 99/1/17 |
| 325 | 8.2.2.3 | استعلام خرید تجهیزات | 15d | 2020-02-20 A | 2020-03-05 A | 323SS | 100% |  |  |  |  | 98/12/1 | 98/12/15 |
| 326 | 8.2.2.4 | خرید تجهیزات سنتز آزمایشگاهی | 25d | 2020-02-25 A | 2020-04-05 A | 325SS+5d | 100% |  |  |  |  | 98/12/6 | 99/1/17 |

| ID | WBS | Task | Duration | Start | Finish | Predecessors | Complete | Remaining | Total slack | Free slack | Constraint | شروع شمسی | پایان شمسی |
| --- | --- | --- | --- | --- | --- | --- | --- | --- | --- | --- | --- | --- | --- |
| 327 | 8.2.3 | **سنتز نمونه های آزمایشگاهی** | 503d | 2020-02-20 A | 2021-07-22 |  | 5% | 477.43d | 92d |  |  | 98/12/1 | 100/4/31 |
| 328 | 8.2.3.1 | سنتز نمونه ها بر اساس طراحی های انجام شده | 15d | 2020-02-20 A | 2020-03-05 A | 321 | 100% |  |  |  |  | 98/12/1 | 98/12/15 |
| 329 | 8.2.3.2 | انجام آزمونهای تأییدیه نمونه ها | 503d | 2020-02-20 A | 2021-07-22 | 328SS | 3% | 488d | 92d | 15d | finish no earlier than 2021-07-22 | 98/12/1 | 100/4/31 |
| 330 | 8.2.3.3 | سنتز نمونه های بهینه | 488d | 2020-03-06 A | 2021-07-22 | 329SS | 4% | 468d | 92d | 0d | finish no earlier than 2021-07-22 | 98/12/16 | 100/4/31 |
| 331 | 8.2.3.4 | دریافت تأییدیه کیفیت از آزمایشگاه مرجع | 488d | 2020-03-06 A | 2021-07-22 | 330SS | 4% | 468d | 92d | 0d | finish no earlier than 2021-07-22 | 98/12/16 | 100/4/31 |
| 332 | 8.2.3.5 | تهیه گزارش فاز آزمایشگاهی | 473d | 2020-04-06 A | 2021-07-22 | 331SS+15d | 6% | 443d | 92d | 30d | finish no earlier than 2021-07-22 | 99/1/18 | 100/4/31 |
| 333 | 8.3 | **فاز نیمه صنعتی** | 505d | 2020-05-06 A | 2021-09-22 |  | 7% | 472.11d | 30d |  |  | 99/2/17 | 100/6/31 |
| 334 | 8.3.1 | **طراحی خط تولید بر اساس تجهیزات موجود** | 474d | 2020-05-06 A | 2021-08-22 |  | 3% | 461.33d | 61d |  |  | 99/2/17 | 100/5/31 |
| 335 | 8.3.1.1 | طراحی پایه | 474d | 2020-05-06 A | 2021-08-22 | 332SS | 3% | 459d | 61d | 15d | finish no earlier than 2021-08-22 | 99/2/17 | 100/5/31 |
| 336 | 8.3.1.2 | طراحی تفضیلی | 459d | 2020-05-21 A | 2021-08-22 | 335SS | 3% | 444d | 61d | 0d | finish no earlier than 2021-08-22 | 99/3/1 | 100/5/31 |
| 337 | 8.3.1.3 | جانمایی تجهیزات | 451d | 2020-05-29 A | 2021-08-22 | 336SS+8d | 2% | 444d | 61d |  | finish no earlier than 2021-08-22 | 99/3/9 | 100/5/31 |
| 338 | 8.3.2 | **تهیه و ساخت کلیه تجهیزات و مواد مصرفی** | 444d | 2020-06-05 A | 2021-08-22 |  | 5% | 420.67d | 61d |  |  | 99/3/16 | 100/5/31 |
| 339 | 8.3.2.1 | استعلام قیمت تجهیزات مورد نیاز | 10d | 2020-06-05 A | 2020-06-14 A | 337 | 100% |  |  |  |  | 99/3/16 | 99/3/25 |
| 340 | 8.3.2.2 | خرید یا سفارش ساخت تجهیزات | 439d | 2020-06-10 A | 2021-08-22 | 339SS+5d | 6% | 414d | 61d | 25d | finish no earlier than 2021-08-22 | 99/3/21 | 100/5/31 |
| 341 | 8.3.2.3 | استعلام قیمت مواد مصرفی جهت تولید نیمه صنعتی | 444d | 2020-06-05 A | 2021-08-22 | 339SS | 2% | 434d | 61d | 0d | finish no earlier than 2021-08-22 | 99/3/16 | 100/5/31 |
| 342 | 8.3.2.4 | خرید مواد مصرفی مورد نیاز | 439d | 2020-06-10 A | 2021-08-22 | 341SS+5d | 6% | 414d | 61d | 40d | finish no earlier than 2021-08-22 | 99/3/21 | 100/5/31 |
| 343 | 8.3.3 | **نصب و راه اندازی تجهیزات** | 414d | 2020-07-05 A | 2021-08-22 |  | 3% | 402.4d | 61d |  |  | 99/4/15 | 100/5/31 |
| 344 | 8.3.3.1 | نصب تجهیزات خریداری شده | 414d | 2020-07-05 A | 2021-08-22 | 340SS | 1% | 409d | 61d | 5d | finish no earlier than 2021-08-22 | 99/4/15 | 100/5/31 |
| 345 | 8.3.3.2 | تکمیل لوله کشی ها و تاسیسات زیربنایی در صورت نیاز | 409d | 2020-07-10 A | 2021-08-22 | 344SS | 1% | 404d | 61d |  | finish no earlier than 2021-08-22 | 99/4/20 | 100/5/31 |
| 346 | 8.3.3.3 | تطبیق تجهیزات با طراحی های انجام شده و راه اندازی سرد واحد | 5d | 2021-07-22 A | 2021-08-22 A | 344SS | 100% |  |  |  | finish no earlier than 2021-08-22 | 100/4/31 | 100/5/31 |
| 347 | 8.3.3.4 | رفع اشکالات احتمالی | 32d | 2021-07-22 A | 2021-08-22 | 346SS | 16% | 27d | 61d | 0d | finish no earlier than 2021-08-22 | 100/4/31 | 100/5/31 |
| 348 | 8.3.3.5 | راه اندازی گرم سیستم و رفع اشکالات | 32d | 2021-07-22 A | 2021-08-22 | 345SS, 347SS | 16% | 27d | 61d | 0d | finish no earlier than 2021-08-22 | 100/4/31 | 100/5/31 |
| 349 | 8.3.4 | **تولید نیمه صنعتی** | 430d | 2020-07-20 A | 2021-09-22 |  | 44% | 242.17d | 30d |  |  | 99/4/30 | 100/6/31 |
| 350 | 8.3.4.1 | تولید محصول در مقیاس پایلوت براساس اعلام نیاز مناطق عملیاتی | 123d | 2020-07-20 A | 2021-09-22 | 342SS, 348SS | 49% | 63d | 30d |  | finish no earlier than 2021-09-22 | 99/4/30 | 100/6/31 |
| 351 | 8.3.4.2 | انجام تست میدانی و دریافت تأییدیه از مناطق عملیاتی | 62d | 2021-07-23 A | 2021-09-22 | 350SS+30d | 50% | 31d | 30d | 0d | finish no earlier than 2021-09-22 | 100/5/1 | 100/6/31 |
| 352 | 8.3.4.3 | گزارش نهایی | 92d | 2020-10-03 A | 2021-09-22 | 351SS | 33% | 62d | 30d |  | finish no earlier than 2021-09-22 | 99/7/12 | 100/6/31 |

| ID | WBS | Task | Duration | Start | Finish | Predecessors | Complete | شروع شمسی | پایان شمسی |
| --- | --- | --- | --- | --- | --- | --- | --- | --- | --- |
| 353 | 9 | **کسب دانش فنی و تولید برطرف کننده آسفالتین** | 332d | 2019-10-23 A | 2020-10-04 A |  | 100% | 98/8/1 | 99/7/13 |
| 354 | 9.1 | **فاز مطالعاتی** | 150d | 2019-10-23 A | 2020-04-05 A |  | 100% | 98/8/1 | 99/1/17 |
| 355 | 9.1.1 | **مطالعات کتابخانه ای** | 70d | 2019-10-23 A | 2019-12-31 A |  | 100% | 98/8/1 | 98/10/10 |
| 356 | 9.1.1.1 | مطالعات اولیه جمع آوری اسناد | 20d | 2019-10-23 A | 2019-11-11 A |  | 100% | 98/8/1 | 98/8/20 |
| 357 | 9.1.1.2 | بررسی روش های رایج جدید | 20d | 2019-11-12 A | 2019-12-01 A | 356 | 100% | 98/8/21 | 98/9/10 |
| 358 | 9.1.1.3 | تهیه گزارش فاز مطالعاتی | 30d | 2019-12-02 A | 2019-12-31 A | 357 | 100% | 98/9/11 | 98/10/10 |
| 359 | 9.1.2 | **خرید و ساخت** | 80d | 2020-01-01 A | 2020-04-05 A |  | 100% | 98/10/11 | 99/1/17 |
| 360 | 9.1.2.1 | انجام شبیه سازی راکتور کاویتاسیون و طراحی سامانه | 30d | 2020-01-01 A | 2020-01-30 A | 358 | 100% | 98/10/11 | 98/11/10 |
| 361 | 9.1.2.2 | استعلام قیمت مواد و تجهیزات | 25d | 2020-01-31 A | 2020-02-24 A | 360 | 100% | 98/11/11 | 98/12/5 |
| 362 | 9.1.2.3 | خرید مواد و تجهیزات آزمایشگاهی | 25d | 2020-02-25 A | 2020-04-05 A | 361 | 100% | 98/12/6 | 99/1/17 |
| 363 | 9.2 | **فاز آزمایشگاهی** | 80d | 2020-04-06 A | 2020-06-24 A |  | 100% | 99/1/18 | 99/4/4 |
| 364 | 9.2.1 | **ساخت و راه اندازی سامانه** | 25d | 2020-04-06 A | 2020-04-30 A |  | 100% | 99/1/18 | 99/2/11 |
| 365 | 9.2.1.1 | ساخت و برپایی سامانه | 12d | 2020-04-06 A | 2020-04-17 A | 362 | 100% | 99/1/18 | 99/1/29 |
| 366 | 9.2.1.2 | راه اندازی اولیه سامانه بر اساس طراحی | 13d | 2020-04-18 A | 2020-04-30 A | 365 | 100% | 99/1/30 | 99/2/11 |
| 367 | 9.2.2 | **اجرای آزمون های مرتبط** | 37d | 2020-05-01 A | 2020-06-06 A |  | 100% | 99/2/12 | 99/3/17 |
| 368 | 9.2.2.1 | شناسایی متغیرهای عملیاتی | 12d | 2020-05-01 A | 2020-05-12 A | 366 | 100% | 99/2/12 | 99/2/23 |
| 369 | 9.2.2.2 | شناسایی متغیرهای طراحی راکتور | 12d | 2020-05-13 A | 2020-05-24 A | 368 | 100% | 99/2/24 | 99/3/4 |
| 370 | 9.2.2.3 | شناسایی خواص شیمیایی -فیزیکی سیستم | 13d | 2020-05-25 A | 2020-06-06 A | 369 | 100% | 99/3/5 | 99/3/17 |
| 371 | 9.2.3 | **تهیه گزارش فاز آزمایشگاهی** | 18d | 2020-06-07 A | 2020-06-24 A |  | 100% | 99/3/18 | 99/4/4 |
| 372 | 9.2.3.1 | تهیه گزارش فاز آزمایشگاهی | 18d | 2020-06-07 A | 2020-06-24 A | 370 | 100% | 99/3/18 | 99/4/4 |
| 373 | 9.3 | **فاز پایلوت** | 102d | 2020-06-25 A | 2020-10-04 A |  | 100% | 99/4/5 | 99/7/13 |
| 374 | 9.3.1 | **افزایش مقیاس از آزمایشگاهی به پایلوت** | 53d | 2020-06-25 A | 2020-08-16 A |  | 100% | 99/4/5 | 99/5/26 |
| 375 | 9.3.1.1 | طراحی پایلوت به کمک داده های فاز آزمایشگاهی | 25d | 2020-06-25 A | 2020-07-19 A | 372 | 100% | 99/4/5 | 99/4/29 |
| 376 | 9.3.1.2 | استعلام قیمی و خرید تجهیزات | 16d | 2020-07-20 A | 2020-08-04 A | 375 | 100% | 99/4/30 | 99/5/14 |
| 377 | 9.3.1.3 | برپایی و راه اندازی پایلوت | 12d | 2020-08-05 A | 2020-08-16 A | 376 | 100% | 99/5/15 | 99/5/26 |

| ID | WBS | Task | Duration | Start | Finish | Predecessors | Complete | شروع شمسی | پایان شمسی |
| --- | --- | --- | --- | --- | --- | --- | --- | --- | --- |
| 378 | 9.3.2 | **بهینه سازی** | 38d | 2020-08-17 A | 2020-09-23 A |  | 100% | 99/5/27 | 99/7/2 |
| 379 | 9.3.2.1 | رسیدن به اهداف طراحی در مقیاس پایلوت | 16d | 2020-08-17 A | 2020-09-01 A | 377 | 100% | 99/5/27 | 99/6/11 |
| 380 | 9.3.2.2 | بهینه سازی متغیرهای عملیاتی | 12d | 2020-09-02 A | 2020-09-13 A | 379 | 100% | 99/6/12 | 99/6/23 |
| 381 | 9.3.2.3 | انجام آزمایش های نهایی | 10d | 2020-09-14 A | 2020-09-23 A | 380 | 100% | 99/6/24 | 99/7/2 |
| 382 | 9.3.3 | **جمع بندی** | 11d | 2020-09-24 A | 2020-10-04 A |  | 100% | 99/7/3 | 99/7/13 |
| 383 | 9.3.3.1 | جمع بندی نتایج و دست آوردها | 6d | 2020-09-24 A | 2020-09-29 A | 381 | 100% | 99/7/3 | 99/7/8 |
| 384 | 9.3.3.2 | گزارش نهایی طرح | 5d | 2020-09-30 A | 2020-10-04 A | 383 | 100% | 99/7/9 | 99/7/13 |
| 385 | 10 | **کسب دانش فنی و تولید کاهش دهنده غلظت سولفید هیدروژن در نفت خام** | 360d | 2019-10-23 A | 2020-11-01 A |  | 100% | 98/8/1 | 99/8/11 |
| 386 | 10.1 | **فاز مطالعاتی** | 105d | 2019-10-23 A | 2020-02-04 A |  | 100% | 98/8/1 | 98/11/15 |
| 387 | 10.1.1 | **جمع آوری اطلاعات** | 30d | 2019-10-23 A | 2019-11-21 A |  | 100% | 98/8/1 | 98/8/30 |
| 388 | 10.1.1.1 | مطالعات کتابخانه ای | 30d | 2019-10-23 A | 2019-11-21 A |  | 100% | 98/8/1 | 98/8/30 |
| 389 | 10.1.1.2 | جمع آوری سوابق اجرای طرح | 30d | 2019-10-23 A | 2019-11-21 A | 388SS | 100% | 98/8/1 | 98/8/30 |
| 390 | 10.1.2 | **تکمیل مطالعات** | 75d | 2019-11-22 A | 2020-02-04 A |  | 100% | 98/9/1 | 98/11/15 |
| 391 | 10.1.2.1 | بررسی اطلاعات و استخراج روش های مناسب سنتز مواد | 60d | 2019-11-22 A | 2020-01-20 A | 389 | 100% | 98/9/1 | 98/10/30 |
| 392 | 10.1.2.2 | بررسی استانداردها و روشهای شناسایی و تأیید مواد | 60d | 2019-11-22 A | 2020-01-20 A | 391SS | 100% | 98/9/1 | 98/10/30 |
| 393 | 10.1.2.3 | تهیه گزارش فاز مطالعاتی | 15d | 2020-01-21 A | 2020-02-04 A | 392 | 100% | 98/11/1 | 98/11/15 |
| 394 | 10.2 | **فاز آزمایشگاهی** | 75d | 2020-02-05 A | 2020-05-05 A |  | 100% | 98/11/16 | 99/2/16 |
| 395 | 10.2.1 | **طراحی آزمایشها** | 15d | 2020-02-05 A | 2020-02-19 A |  | 100% | 98/11/16 | 98/11/30 |
| 396 | 10.2.1.1 | استفاده از نرم افزارهاي مرتبط جهت برنامه ريزي آزمایشها | 7d | 2020-02-05 A | 2020-02-11 A | 393 | 100% | 98/11/16 | 98/11/22 |
| 397 | 10.2.1.2 | تدوين دستور كار تهيه آزمايشگاهي | 8d | 2020-02-12 A | 2020-02-19 A | 396 | 100% | 98/11/23 | 98/11/30 |
| 398 | 10.2.2 | **خرید مواد و تجهیزات** | 30d | 2020-02-20 A | 2020-04-05 A |  | 100% | 98/12/1 | 99/1/17 |
| 399 | 10.2.2.1 | استعلام قیمت مواد | 15d | 2020-02-20 A | 2020-03-05 A | 397 | 100% | 98/12/1 | 98/12/15 |
| 400 | 10.2.2.2 | سفارش خرید مواد | 25d | 2020-02-25 A | 2020-04-05 A | 399SS+5d | 100% | 98/12/6 | 99/1/17 |
| 401 | 10.2.2.3 | استعلام خرید تجهیزات | 15d | 2020-02-20 A | 2020-03-05 A | 399SS | 100% | 98/12/1 | 98/12/15 |
| 402 | 10.2.2.4 | خرید تجهیزات سنتز آزمایشگاهی | 25d | 2020-02-25 A | 2020-04-05 A | 401SS+5d | 100% | 98/12/6 | 99/1/17 |

| ID | WBS | Task | Duration | Start | Finish | Predecessors | Complete | شروع شمسی | پایان شمسی |
| --- | --- | --- | --- | --- | --- | --- | --- | --- | --- |
| 403 | 10.2.3 | **سنتز نمونه های آزمایشگاهی** | 60d | 2020-02-20 A | 2020-05-05 A |  | 100% | 98/12/1 | 99/2/16 |
| 404 | 10.2.3.1 | سنتز نمونه ها بر اساس طراحی های انجام شده | 15d | 2020-02-20 A | 2020-03-05 A | 397 | 100% | 98/12/1 | 98/12/15 |
| 405 | 10.2.3.2 | انجام آزمونهای تأییدیه نمونه ها | 15d | 2020-02-20 A | 2020-03-05 A | 404SS | 100% | 98/12/1 | 98/12/15 |
| 406 | 10.2.3.3 | سنتز نمونه های بهینه | 20d | 2020-03-06 A | 2020-04-10 A | 405 | 100% | 98/12/16 | 99/1/22 |
| 407 | 10.2.3.4 | دریافت تأییدیه کیفیت از آزمایشگاه مرجع | 20d | 2020-03-06 A | 2020-04-10 A | 406SS | 100% | 98/12/16 | 99/1/22 |
| 408 | 10.2.3.5 | تهیه گزارش فاز آزمایشگاهی | 30d | 2020-04-06 A | 2020-05-05 A | 407SS+15d | 100% | 99/1/18 | 99/2/16 |
| 409 | 10.3 | **فاز نیمه صنعتی** | 180d | 2020-05-06 A | 2020-11-01 A |  | 100% | 99/2/17 | 99/8/11 |
| 410 | 10.3.1 | **طراحی خط تولید بر اساس تجهیزات موجود** | 30d | 2020-05-06 A | 2020-06-04 A |  | 100% | 99/2/17 | 99/3/15 |
| 411 | 10.3.1.1 | طراحی پایه | 15d | 2020-05-06 A | 2020-05-20 A | 408 | 100% | 99/2/17 | 99/2/31 |
| 412 | 10.3.1.2 | طراحی تفضیلی | 15d | 2020-05-21 A | 2020-06-04 A | 411 | 100% | 99/3/1 | 99/3/15 |
| 413 | 10.3.1.3 | جانمایی تجهیزات | 7d | 2020-05-29 A | 2020-06-04 A | 412SS+8d | 100% | 99/3/9 | 99/3/15 |
| 414 | 10.3.2 | **تهیه و ساخت کلیه تجهیزات و مواد مصرفی** | 30d | 2020-06-05 A | 2020-07-04 A |  | 100% | 99/3/16 | 99/4/14 |
| 415 | 10.3.2.1 | استعلام قیمت تجهیزات مورد نیاز | 10d | 2020-06-05 A | 2020-06-14 A | 413 | 100% | 99/3/16 | 99/3/25 |
| 416 | 10.3.2.2 | خرید یا سفارش ساخت تجهیزات | 25d | 2020-06-10 A | 2020-07-04 A | 415SS+5d | 100% | 99/3/21 | 99/4/14 |
| 417 | 10.3.2.3 | استعلام قیمت مواد مصرفی جهت تولید نیمه صنعتی | 10d | 2020-06-05 A | 2020-06-14 A | 415SS | 100% | 99/3/16 | 99/3/25 |
| 418 | 10.3.2.4 | خرید مواد مصرفی مورد نیاز | 25d | 2020-06-10 A | 2020-07-04 A | 417SS+5d | 100% | 99/3/21 | 99/4/14 |
| 419 | 10.3.3 | **نصب و راه اندازی تجهیزات** | 15d | 2020-07-05 A | 2020-07-19 A |  | 100% | 99/4/15 | 99/4/29 |
| 420 | 10.3.3.1 | نصب تجهیزات خریداری شده | 5d | 2020-07-05 A | 2020-07-09 A | 416 | 100% | 99/4/15 | 99/4/19 |
| 421 | 10.3.3.2 | تکمیل لوله کشی ها و تاسیسات زیربنایی در صورت نیاز | 5d | 2020-07-10 A | 2020-07-14 A | 420 | 100% | 99/4/20 | 99/4/24 |
| 422 | 10.3.3.3 | تطبیق تجهیزات با طراحی های انجام شده و راه اندازی سرد واحد | 5d | 2020-07-10 A | 2020-07-14 A | 420 | 100% | 99/4/20 | 99/4/24 |
| 423 | 10.3.3.4 | رفع اشکالات احتمالی | 5d | 2020-07-10 A | 2020-07-14 A | 422SS | 100% | 99/4/20 | 99/4/24 |
| 424 | 10.3.3.5 | راه اندازی گرم سیستم و رفع اشکالات | 5d | 2020-07-15 A | 2020-07-19 A | 421, 423 | 100% | 99/4/25 | 99/4/29 |
| 425 | 10.3.4 | **تولید نیمه صنعتی** | 105d | 2020-07-20 A | 2020-11-01 A |  | 100% | 99/4/30 | 99/8/11 |
| 426 | 10.3.4.1 | تولید محصول در مقیاس پایلوت براساس اعلام نیاز مناطق عملیاتی | 60d | 2020-07-20 A | 2020-09-17 A | 418, 424 | 100% | 99/4/30 | 99/6/27 |
| 427 | 10.3.4.2 | انجام تست میدانی و دریافت تأییدیه از مناطق عملیاتی | 60d | 2020-08-19 A | 2020-10-17 A | 426SS+30d | 100% | 99/5/29 | 99/7/26 |
| 428 | 10.3.4.3 | گزارش نهایی | 30d | 2020-10-03 A | 2020-11-01 A | 427SS+45d | 100% | 99/7/12 | 99/8/11 |
